Schedule from MS Project, 2025-01-01 to 2025-12-27.

## Calendars

- 7天工作制: Mon-Fri 08:00-12:00, 13:00-17:00; Sat-Sun 08:00-12:00, 14:00-18:00.

## Schedule

| ID | WBS | Task | Type | Duration | Start | Finish | Predecessors |
| --- | --- | --- | --- | --- | --- | --- | --- |
| 1 | 1 | 1. Package 2 - New Substation Project | manual | 360.88d | 2025-01-01 | 2025-12-27 |  |
| 2 | 2 | 2. Civil Works | manual | 200.88d | 2025-01-01 | 2025-07-20 |  |
| 3 | 3 | 3. HV/MV equipment procurements incl design phases | manual | 273d | 2025-01-01 | 2025-09-30 |  |
| 4 | 4 | 4. HV/MV equipment Installation, cold commissioning, energizing | manual | 92d | 2025-08-01 | 2025-10-31 |  |
| 5 | 15 | 5. Protection, Instrument and LAN Equipment for new switchgear and Isolating Transformers | manual | 243.88d | 2025-04-01 | 2025-11-30 |  |
| 6 | 16 | 6. Move from old to new substation | manual | 84.88d | 2025-09-20 | 2025-12-13 |  |
| 7 | 7 | 7. Put in Operation Isolating transformers and Incoming Lines protection relays | manual | 7.88d | 2025-12-13 | 2025-12-20 | 6 |
| 8 | 8 | 8. Integration of new substation protections in the PMAC | manual | 6.88d | 2025-12-21 | 2025-12-27 |  |
